Schedule from MS Project, 2016-01-01 to 2016-06-08.

## Calendars

- Padrão: Mon-Sun 09:00-12:00, 13:00-18:00.

## Schedule

| ID | WBS | Task | Duration | Start | Finish | Predecessors | Total slack | Free slack |
| --- | --- | --- | --- | --- | --- | --- | --- | --- |
| 1 | 1 | **JUIZADOS DA COMARCA DE ARAPIRACA** | 160d | 2016-01-01 | 2016-06-08 |  |  |  |
| 2 | 1.1 | **SERVIÇOS PRELIMINARES** | 9d | 2016-01-01 | 2016-01-09 |  | -0.12d | 0d |
| 3 | 1.1.1 | Instalação da placa da obra | 0.5d | 2016-01-01 | 2016-01-01 |  | 8.38d |  |
| 4 | 1.1.2 | Demolição de paredes | 1d | 2016-01-01 | 2016-01-01 |  | -0.12d | 0d |
| 5 | 1.1.3 | Demolição de piso | 1d | 2016-01-02 | 2016-01-02 | 4 | 1.88d | 0d |
| 6 | 1.1.4 | Recuperação de piso | 5d | 2016-01-03 | 2016-01-07 | 5 | 1.88d |  |
| 7 | 1.1.5 | Demolição de laje | 1d | 2016-01-02 | 2016-01-02 | 4 | -0.12d | 0d |
| 8 | 1.1.6 | Recuperação de laje | 5d | 2016-01-03 | 2016-01-07 | 7 | -0.12d | 0d |
| 9 | 1.1.7 | Recuperação de ferragens expostas | 2d | 2016-01-08 | 2016-01-09 | 8 | -0.12d | 0d |
| 10 | 1.2 | **RESERVATÓRIO INFERIOR** | 38d | 2016-01-10 | 2016-02-16 | 2 | -0.12d | 0d |
| 11 | 1.2.1 | Execução de formas | 4d | 2016-01-10 | 2016-01-13 |  | -0.12d | 0d |
| 12 | 1.2.2 | Montagem e colocação da armação | 4d | 2016-01-14 | 2016-01-17 | 11 | -0.12d | 0d |
| 13 | 1.2.3 | Concretagem | 1d | 2016-01-18 | 2016-01-18 | 12 | -0.12d | 0d |
| 14 | 1.2.4 | Impermeabilização | 1d | 2016-02-16 | 2016-02-16 | 13FS+28d | -0.12d | 0d |
| 15 | 1.3 | **SUPERESTRUTURA** | 34d | 2016-01-23 | 2016-02-25 | 10FS-25d | -0.12d | 0d |
| 16 | 1.3.1 | Inspeção de sapatas | 3d | 2016-01-23 | 2016-01-25 |  | 121.88d |  |
| 17 | 1.3.2 | Execução de formas | 30d | 2016-01-23 | 2016-02-21 |  | -0.12d | 0d |
| 18 | 1.3.3 | Montagem e colocação da armação | 30d | 2016-01-26 | 2016-02-24 | 17SS+3d | -0.12d | 0d |
| 19 | 1.3.4 | Concretagem | 30d | 2016-01-27 | 2016-02-25 | 18SS+1d | -0.12d | 0d |
| 20 | 1.4 | **VEDAÇÃO** | 31d | 2016-02-24 | 2016-03-25 |  | -0.12d | 0d |
| 21 | 1.4.1 | Execução de alvenaria | 30d | 2016-02-24 | 2016-03-24 | 19SS+28d | -0.12d | 0d |
| 22 | 1.4.2 | Execução de divisória em granito | 1d | 2016-03-25 | 2016-03-25 | 21 | -0.12d | 0d |
| 23 | 1.5 | **REVESTIMENTO INTERNO** | 25d | 2016-04-05 | 2016-04-29 | 66, 68, 70, 76, 92, 103FS-20d | -0.12d | 0d |
| 24 | 1.5.1 | Execução de chapisco | 4d | 2016-04-05 | 2016-04-08 |  | 33.88d |  |
| 25 | 1.5.2 | Execução de emboço | 5d | 2016-04-05 | 2016-04-09 |  | 32.88d |  |
| 26 | 1.5.3 | Execução de reboco | 3d | 2016-04-05 | 2016-04-07 |  | 34.88d |  |
| 27 | 1.5.4 | Colocação de peitoril | 5d | 2016-04-05 | 2016-04-09 |  | 32.88d |  |
| 28 | 1.5.5 | Aplicação de revestimento cerâmico | 25d | 2016-04-05 | 2016-04-29 |  | -0.12d | 0d |
| 29 | 1.5.6 | Execução de rodapé | 15d | 2016-04-05 | 2016-04-19 |  | 22.88d |  |

| ID | WBS | Task | Duration | Start | Finish | Predecessors | Total slack | Free slack |
| --- | --- | --- | --- | --- | --- | --- | --- | --- |
| 30 | 1.6 | **REVESTIMENTO EXTERNO** | 30d | 2016-04-05 | 2016-05-04 | 23SS | 34.88d | 0d |
| 31 | 1.6.1 | Aplicação de revestimento cerâmico | 30d | 2016-04-05 | 2016-05-04 |  | 34.88d |  |
| 32 | 1.7 | **PAVIMENTAÇÃO** | 30d | 2016-04-20 | 2016-05-19 | 30SS+15d | 17.88d | 0d |
| 33 | 1.7.1 | Regularização de base | 2d | 2016-04-20 | 2016-04-21 |  | 30.88d | 0d |
| 34 | 1.7.2 | Execução de passeio | 7d | 2016-04-22 | 2016-04-28 | 33 | 30.88d | 0d |
| 35 | 1.7.3 | Aplicação de piso tátil | 4d | 2016-04-29 | 2016-05-02 | 34 | 30.88d | 0d |
| 36 | 1.7.4 | Assentamento de meio fio | 3d | 2016-05-03 | 2016-05-05 | 35 | 30.88d | 0d |
| 37 | 1.7.5 | Caiação de meio fio | 1d | 2016-05-06 | 2016-05-06 | 36 | 30.88d |  |
| 38 | 1.7.6 | Demarcação de pavimentos | 2d | 2016-04-20 | 2016-04-21 |  | 45.88d |  |
| 39 | 1.7.7 | Execução de piso em granilite | 30d | 2016-04-20 | 2016-05-19 |  | 17.88d |  |
| 40 | 1.7.8 | Piso em bloco intertravado | 30d | 2016-04-20 | 2016-05-19 |  | 17.88d |  |
| 41 | 1.7.9 | Piso cimentado desempolado | 5d | 2016-04-20 | 2016-04-24 |  | 42.88d |  |
| 42 | 1.7.10 | Pintura acrílica em piso cimentado | 13d | 2016-04-20 | 2016-05-02 |  | 34.88d |  |
| 43 | 1.7.11 | Corrimão em aço galvanizado | 3d | 2016-04-20 | 2016-04-22 |  | 44.88d |  |
| 44 | 1.7.12 | Execução de bicicletário | 0.5d | 2016-04-20 | 2016-04-20 |  | 47.38d |  |
| 45 | 1.7.13 | Instalação de postes de ferro galvanizado | 1d | 2016-04-20 | 2016-04-20 |  | 46.88d |  |
| 46 | 1.7.14 | Aplicação de revestimento cerâmico para piso | 3d | 2016-04-22 | 2016-04-24 | 33 | 42.88d |  |
| 47 | 1.8 | **ESQUADRIAS** | 7d | 2016-03-11 | 2016-03-17 | 20FS-15d | 82.88d |  |
| 48 | 1.8.1 | Revestimento em laminado | 6d | 2016-03-11 | 2016-03-16 |  | 95.88d |  |
| 49 | 1.8.2 | Execução de grade fixa em barra de ferro | 0.5d | 2016-03-11 | 2016-03-11 |  | 101.38d |  |
| 50 | 1.8.3 | Execução de grade de ferro com tela | 7d | 2016-03-11 | 2016-03-17 |  | 94.88d |  |
| 51 | 1.8.4 | Instalação de portas | 2d | 2016-03-11 | 2016-03-12 |  | 99.88d |  |
| 52 | 1.8.5 | Instalação de vidros | 1d | 2016-03-11 | 2016-03-11 |  | 100.88d |  |
| 53 | 1.8.6 | Instalação de esquadria fixa em alumínio | 5d | 2016-03-11 | 2016-03-15 |  | 96.88d |  |
| 54 | 1.8.7 | Instalação de portão em aço galvanizado | 0.5d | 2016-03-11 | 2016-03-11 |  | 101.38d |  |

| ID | WBS | Task | Duration | Start | Finish | Predecessors | Total slack | Free slack |
| --- | --- | --- | --- | --- | --- | --- | --- | --- |
| 55 | 1.9 | **PINTURA** | 30d | 2016-04-30 | 2016-05-29 | 23 | -0.12d | 0d |
| 56 | 1.9.1 | Aplicação de pintura para interiores | 30d | 2016-04-30 | 2016-05-29 |  | -0.12d | 0d |
| 57 | 1.9.2 | Aplicação de pintura de proteção | 2d | 2016-04-30 | 2016-05-01 |  | 27.88d |  |
| 58 | 1.10 | **COBERTURA** | 25d | 2016-02-26 | 2016-03-21 | 15 | 78.88d |  |
| 59 | 1.10.1 | Execução de estrutura em madeira | 20d | 2016-02-26 | 2016-03-16 |  | 78.88d | 0d |
| 60 | 1.10.2 | Colocação de telhas de fibrocimento | 5d | 2016-03-17 | 2016-03-21 | 59 | 78.88d |  |
| 61 | 1.10.3 | Execução de calha em concreto armado | 4d | 2016-02-26 | 2016-02-29 |  | 99.88d |  |
| 62 | 1.10.4 | Execução de rufo em concreto armado | 4d | 2016-02-26 | 2016-02-29 |  | 99.88d |  |
| 63 | 1.10.5 | Impermeabilização | 2d | 2016-02-26 | 2016-02-27 |  | 101.88d |  |
| 64 | 1.11 | **ACÚSTICA** | 4d | 2016-05-18 | 2016-05-21 | 32FS-2d | 17.88d |  |
| 65 | 1.11.1 | Execução de piso laminado de madeira | 4d | 2016-05-18 | 2016-05-21 |  | 17.88d |  |
| 66 | 1.12 | **ANTENA COLETIVA** | 3d | 2016-03-11 | 2016-03-13 | 20FS-15d | 21.88d |  |
| 67 | 1.12.1 | Execução de instalações para a antena coletiva | 3d | 2016-03-11 | 2016-03-13 |  | 41.88d |  |
| 68 | 1.13 | **SPDA** | 5d | 2016-03-11 | 2016-03-15 | 20FS-15d | 19.88d |  |
| 69 | 1.13.1 | Execução de instalações do SPDA | 5d | 2016-03-11 | 2016-03-15 |  | 39.88d |  |
| 70 | 1.14 | **CABEAMENTO ESTRUTURADO** | 3d | 2016-03-11 | 2016-03-13 | 20FS-15d | 21.88d |  |
| 71 | 1.14.1 | Execução das instalações de cabeamento estruturado | 3d | 2016-03-11 | 2016-03-13 |  | 41.88d |  |
| 72 | 1.15 | **DRENAGEM** | 10d | 2016-02-26 | 2016-03-06 | 15 | 93.88d |  |
| 73 | 1.15.1 | Rasgos em alvenaria | 4d | 2016-02-26 | 2016-02-29 |  | 99.88d |  |
| 74 | 1.15.2 | Instalação das tubulações de drenagem | 10d | 2016-02-26 | 2016-03-06 |  | 93.88d |  |
| 75 | 1.15.3 | Execução de caixa de areia em alvenaria | 0.5d | 2016-02-26 | 2016-02-26 |  | 103.38d |  |
| 76 | 1.16 | **INSTALAÇÕES HIDRÁULICAS** | 5d | 2016-03-11 | 2016-03-15 | 20FS-15d | 19.88d | 0d |
| 77 | 1.16.1 | Instalação das tubulações de água fria | 5d | 2016-03-11 | 2016-03-15 |  | 24.88d |  |
| 78 | 1.16.2 | Instalação das peças de utilização | 1d | 2016-03-11 | 2016-03-11 |  | 28.88d |  |

| ID | WBS | Task | Duration | Start | Finish | Predecessors | Total slack | Free slack |
| --- | --- | --- | --- | --- | --- | --- | --- | --- |
| 79 | 1.17 | **INSTALAÇÕES SANITÁRIAS** | 15d | 2016-03-16 | 2016-03-30 | 76 | 66.88d | 0d |
| 80 | 1.17.1 | Instalação das tubulações sanitárias | 7d | 2016-03-16 | 2016-03-22 |  | 74.88d |  |
| 81 | 1.17.2 | Execução de caixas de passagem e gordura | 1d | 2016-03-16 | 2016-03-16 |  | 80.88d |  |
| 82 | 1.17.3 | Execução de fossa séptica em concreto armado | 15d | 2016-03-16 | 2016-03-30 |  | 66.88d |  |
| 83 | 1.17.4 | Execução de sumidouro em alvenaria | 5d | 2016-03-16 | 2016-03-20 |  | 76.88d |  |
| 84 | 1.17.5 | Instalação das peças sanitárias | 1d | 2016-03-16 | 2016-03-16 |  | 80.88d |  |
| 85 | 1.18 | **INSTALAÇÕES DE COMBATE A INCÊNDIO** | 82d | 2016-03-11 | 2016-05-31 |  | 7.88d |  |
| 86 | 1.18.1 | Instalação de extintores de incêndio | 0.5d | 2016-05-30 | 2016-05-30 | 55 | 9.38d |  |
| 87 | 1.18.2 | Instalação de placas de sinalização | 1d | 2016-05-30 | 2016-05-30 | 55 | 8.88d |  |
| 88 | 1.18.3 | Instalação das luminárias de emergência | 2d | 2016-05-30 | 2016-05-31 | 55 | 7.88d |  |
| 89 | 1.18.4 | Instalação do sistema de detecção e alarme | 10d | 2016-04-30 | 2016-05-09 | 23 | 29.88d |  |
| 90 | 1.18.5 | Instalação de conjunto motor bomba centrífuga | 2d | 2016-04-30 | 2016-05-01 | 23 | 37.88d |  |
| 91 | 1.18.6 | Instalação de hidrante | 0.5d | 2016-03-11 | 2016-03-11 | 20FS-15d | 101.38d |  |
| 92 | 1.18.7 | Instalação de tubulação de incêndio | 10d | 2016-03-11 | 2016-03-20 | 20FS-15d | 34.88d |  |
| 93 | 1.19 | **IRRIGAÇÃO** | 3d | 2016-03-31 | 2016-04-02 | 79 | 66.88d |  |
| 94 | 1.19.1 | Instalação de caixa de passagem | 1d | 2016-03-31 | 2016-03-31 |  | 68.88d |  |
| 95 | 1.19.2 | Instalação de tubulação de irrigação | 2d | 2016-03-31 | 2016-04-01 |  | 66.88d | 0d |
| 96 | 1.19.3 | Instalação de peças de utilização | 1d | 2016-04-02 | 2016-04-02 | 95 | 66.88d |  |
| 97 | 1.19.4 | Instalação de hidrômetro | 0.5d | 2016-03-31 | 2016-03-31 |  | 69.38d |  |
| 98 | 1.20 | **PAISAGISMO** | 2d | 2016-04-30 | 2016-05-01 | 23 | 37.88d |  |
| 99 | 1.20.1 | Colocação de grama esmeralda em placas | 2d | 2016-04-30 | 2016-05-01 |  | 37.88d |  |
| 100 | 1.20.2 | Plantio de mudas diversas | 2d | 2016-04-30 | 2016-05-01 |  | 37.88d |  |
| 101 | 1.21 | **TELEFÔNICO** | 30d | 2016-04-20 | 2016-05-19 | 23FS-10d | 19.88d |  |
| 102 | 1.21.1 | Execução das instalações telefônicas | 30d | 2016-04-20 | 2016-05-19 |  | 19.88d |  |

| ID | WBS | Task | Duration | Start | Finish | Predecessors | Total slack | Free slack |
| --- | --- | --- | --- | --- | --- | --- | --- | --- |
| 103 | 1.22 | **ELÉTRICA** | 45d | 2016-03-11 | 2016-04-24 | 20FS-15d | -0.12d | 0d |
| 104 | 1.22.1 | Execução das instalações de distribuição geral | 15d | 2016-03-11 | 2016-03-25 |  | -0.12d | 0d |
| 105 | 1.22.2 | Execução das instalações de elétrica estabilizada | 5d | 2016-03-11 | 2016-03-15 |  | 9.88d |  |
| 106 | 1.22.3 | Execução das instalações de iluminação externa | 10d | 2016-03-26 | 2016-04-04 | 104, 105 | 19.88d |  |
| 107 | 1.22.4 | Execução de caixas de passagem em alvenaria | 5d | 2016-03-11 | 2016-03-15 |  | 39.88d |  |
| 108 | 1.22.5 | Exec. instalações da subestação e sala do gerador | 10d | 2016-03-26 | 2016-04-04 | 104, 105 | 19.88d |  |
| 109 | 1.22.6 | Execução das instalações de luz e força | 30d | 2016-03-26 | 2016-04-24 | 104, 105 | -0.12d | 0d |
| 110 | 1.23 | **CLIMATIZAÇÃO** | 10d | 2016-05-30 | 2016-06-08 | 55 | -0.12d | 0d |
| 111 | 1.23.1 | Execução das instalações de ar condicionado | 9d | 2016-05-30 | 2016-06-07 |  | -0.12d | 0d |
| 112 | 1.23.2 | Instalação dos aparelhos de ar condicionado | 1d | 2016-06-08 | 2016-06-08 | 111 | -0.12d | 0d |
| 113 | 1.24 | **RODAPÉ, PEITORIL, SOLEIRA E RODAMEIO** | 15d | 2016-04-25 | 2016-05-09 | 23FS-5d | 29.88d |  |
| 114 | 1.24.1 | Execução de rodopia em granito | 2d | 2016-04-25 | 2016-04-26 |  | 37.88d | 0d |
| 115 | 1.24.2 | Execução de peitoril em marmorite | 5d | 2016-04-27 | 2016-05-01 | 114 | 37.88d |  |
| 116 | 1.24.3 | Execução de rodapé em alta resistência | 15d | 2016-04-25 | 2016-05-09 |  | 29.88d |  |
| 117 | 1.25 | **LOUÇAS E METAIS** | 35d | 2016-04-20 | 2016-05-24 | 23FS-10d | 14.88d |  |
| 118 | 1.25.1 | Instalação de bancadas em granito | 10d | 2016-04-20 | 2016-04-29 |  | 14.88d | 0d |
| 119 | 1.25.2 | Instalação de louças sanitárias | 10d | 2016-05-05 | 2016-05-14 | 118FS+5d | 14.88d | 0d |
| 120 | 1.25.3 | Instalação de metais sanitários | 5d | 2016-05-20 | 2016-05-24 | 119FS+5d | 14.88d |  |
| 121 | 1.26 | **CASA DE GÁS** | 5d | 2016-01-10 | 2016-01-14 | 2 | 145.88d |  |
| 122 | 1.26.1 | Rasgo em contrapiso | 0.5d | 2016-01-10 | 2016-01-10 |  | 150.38d |  |
| 123 | 1.26.2 | Concretagem | 1d | 2016-01-10 | 2016-01-10 |  | 149.88d |  |
| 124 | 1.26.3 | Instalação de porta de ferro | 1d | 2016-01-10 | 2016-01-10 |  | 149.88d |  |
| 125 | 1.26.4 | Instalação de tubulação de gás | 5d | 2016-01-10 | 2016-01-14 |  | 145.88d |  |
